# MyProject1

Schedule from MS Project, 2008-07-02 to 2008-11-09, 4 hours a day, costs in hrs, A marks actual dates.
CSE

## Calendars

- Standard: Mon 13:00-17:00; Tue 14:00-19:00; Wed 13:00-17:00; Thu 14:00-20:00; Fri-Sat off; Sun 14:00-18:00.

## Resources

| Resource | Rate |
| --- | --- |
| John N | 1 |
| David E | 1 |
| Sarah B | 1 |
| Larry J | 1 |

## Schedule

| ID | WBS | Task | Duration | Start | Finish | Predecessors | Complete | Remaining | Baseline start | Baseline finish | Baseline duration | Total slack | Free slack | Constraint | Resources | Work | Actual work | Cost | Baseline cost | Actual cost |
| --- | --- | --- | --- | --- | --- | --- | --- | --- | --- | --- | --- | --- | --- | --- | --- | --- | --- | --- | --- | --- |
| 1 | MyProj_1 | **PROJECT START-UP** | 2.25d | 2008-07-02 A | 2008-07-03 |  | 76% | 0.53d | 2008-07-02 | 2008-07-03 | 2.25d | 104d |  |  |  | 17h | 13h | 17 | 17 | 13 |
| 2 | MyProj_1.1 | Set up lab server | 6h | 2008-07-02 A | 2008-07-03 A |  | 100% |  | 2008-07-02 | 2008-07-03 | 6h |  |  |  | Larry J | 6h | 6h | 6 | 6 | 6 |
| 3 | MyProj_1.2 | Configure PC/network for project | 3h | 2008-07-03 A | 2008-07-03 A |  | 100% |  | 2008-07-03 | 2008-07-03 | 3h |  |  |  | David E | 3h | 3h | 3 | 3 | 3 |
| 4 | MyProj_1.3 | Install and set up MS Project | 2h | 2008-07-03 A | 2008-07-03 |  | 50% | 1h | 2008-07-03 | 2008-07-03 | 2h | 104.25d |  |  | Larry J | 2h | 1h | 2 | 2 | 1 |
| 5 | MyProj_1.4 | Set up project files sytem and library controls | 6h | 2008-07-02 A | 2008-07-03 |  | 50% | 3h | 2008-07-02 | 2008-07-03 | 6h | 104.75d |  |  | David E | 6h | 3h | 6 | 6 | 3 |
| 6 | MyProj_2 | **REQUIREMENTS DEFINITION** | 23d | 2008-07-02 A | 2008-07-29 |  | 6% | 21.55d | 2008-07-02 | 2008-07-29 | 23d | 83.25d |  |  |  | 74h | 5.1h | 74 | 74 | 5.1 |
| 7 | MyProj_2.1 | Develop proposed approach | 6h | 2008-07-02 A | 2008-07-03 |  | 25% | 4.5h | 2008-07-02 | 2008-07-03 | 6h | 104.75d |  |  | Sarah B | 6h | 1.5h | 6 | 6 | 1.5 |
| 8 | MyProj_2.2 | Review proposal, sponsor approval | 2h | 2008-07-21 A | 2008-07-21 |  | 25% | 1.5h | 2008-07-21 | 2008-07-21 | 2h | 0d |  | must start on 2008-07-21 | Sarah B; John N; Larry J; David E | 8h | 2h | 8 | 8 | 2 |
| 9 | MyProj_2.3 | Develop preliminary requirements | 4h | 2008-07-21 A | 2008-07-22 | 8 | 10% | 3.6h | 2008-07-21 | 2008-07-22 | 4h | 0d |  |  | Sarah B; John N; Larry J; David E | 16h | 1.6h | 16 | 16 | 1.6 |
| 10 | MyProj_2.4 | Review Requirements, sponsor approval | 2h | 2008-07-22 | 2008-07-22 | 9 |  |  | 2008-07-22 | 2008-07-22 | 2h | 0d |  |  | Sarah B; John N; Larry J; David E | 8h |  | 8 | 8 |  |
| 11 | MyProj_2.5 | **Develop SRD** | 3.5d | 2008-07-22 | 2008-07-27 |  |  |  | 2008-07-22 | 2008-07-27 | 3.5d | 0d |  |  |  | 20h |  | 20 | 20 |  |
| 12 | MyProj_2.5.1 | Prepare SRD Document Draft | 6h | 2008-07-22 | 2008-07-24 | 10 |  |  | 2008-07-22 | 2008-07-24 | 6h | 0d |  |  | John N; Sarah B | 12h |  | 12 | 12 |  |
| 13 | MyProj_2.5.2 | Prepare SRD Review Presentation | 8h | 2008-07-24 | 2008-07-27 | 12 |  |  | 2008-07-24 | 2008-07-27 | 8h | 0d |  |  | Sarah B | 8h |  | 8 | 8 |  |
| 14 | MyProj_2.6 | Prepare SRD Document Final | 6h | 2008-07-27 | 2008-07-29 | 13 |  |  | 2008-07-27 | 2008-07-29 | 6h | 0d |  |  | Sarah B; John N | 12h |  | 12 | 12 |  |
| 15 | MyProj_2.7 | Prepare SRD Review Presentation Final | 4h | 2008-07-29 | 2008-07-29 | 14FF |  |  | 2008-07-29 | 2008-07-29 | 4h | 0.75d |  |  | Sarah B | 4h |  | 4 | 4 |  |
| 16 | MyProj_3 | **PLANNING AND ESTIMATING** | 42d | 2008-07-02 | 2008-08-21 |  |  |  | 2008-07-02 | 2008-08-21 | 42d | 0d |  |  |  | 190h |  | 190 | 190 |  |
| 17 | MyProj_3.1 | **Project Charter Prepararion** | 27d | 2008-07-02 | 2008-08-04 |  |  |  | 2008-07-02 | 2008-08-04 | 27d | 15d |  |  |  | 32h |  | 32 | 32 |  |
| 18 | MyProj_3.1.1 | Create Project Charter Draft | 8h | 2008-07-02 | 2008-07-03 |  |  |  | 2008-07-02 | 2008-07-03 | 8h | 39.25d | 0d |  | John N | 8h |  | 8 | 8 |  |
| 19 | MyProj_3.1.2 | Prepare Draft Charter Review Presentation | 3h | 2008-07-03 | 2008-07-06 | 18 |  |  | 2008-07-03 | 2008-07-06 | 3h | 39.25d |  |  | Sarah B; John N | 6h |  | 6 | 6 |  |
| 20 | MyProj_3.1.3 | Prepare Charter Review Presentation | 3h | 2008-07-30 | 2008-07-31 | 15FF |  |  | 2008-07-30 | 2008-07-31 | 3h | 0d |  |  | John N; Sarah B | 6h |  | 6 | 6 |  |
| 21 | MyProj_3.1.4 | Prepare Final Project Charter document | 6h | 2008-08-03 | 2008-08-04 | 20FF |  |  | 2008-08-03 | 2008-08-04 | 6h | 0d |  |  | John N; Sarah B | 12h |  | 12 | 12 |  |
| 22 | MyProj_3.2 | **Estimate and Schedule Project** | 10d | 2008-08-04 | 2008-08-14 | 21 |  |  | 2008-08-04 | 2008-08-14 | 10d | 0d |  |  |  | 96h |  | 96 | 96 |  |
| 23 | MyProj_3.2.1 | Develop GUI estimate | 12h | 2008-08-04 | 2008-08-07 |  |  |  | 2008-08-04 | 2008-08-07 | 12h | 7d |  |  | David E | 12h |  | 12 | 12 |  |
| 24 | MyProj_3.2.2 | Develop hardware estimate | 6h | 2008-08-04 | 2008-08-05 |  |  |  | 2008-08-04 | 2008-08-05 | 6h | 8.5d |  |  | Larry J | 6h |  | 6 | 6 |  |
| 25 | MyProj_3.2.3 | Develop operating environment estimate | 8h | 2008-08-13 | 2008-08-14 |  |  |  | 2008-08-13 | 2008-08-14 | 8h | 0d |  |  | David E | 8h |  | 8 | 8 |  |
| 26 | MyProj_3.2.4 | Develop middleware estimate | 18h | 2008-08-04 | 2008-08-13 |  |  |  | 2008-08-04 | 2008-08-13 | 18h | 2d |  |  | David E; Larry J | 20h |  | 20 | 20 |  |
| 27 | MyProj_3.2.5 | Develop base feature estimate | 14h | 2008-08-04 | 2008-08-07 |  |  |  | 2008-08-04 | 2008-08-07 | 14h | 0d |  |  | John N | 14h |  | 14 | 14 |  |
| 28 | MyProj_3.2.6 | Develop networking feature estimate | 10h | 2008-08-07 | 2008-08-11 | 27 |  |  | 2008-08-07 | 2008-08-11 | 10h | 4d |  |  | Sarah B | 10h |  | 10 | 10 |  |
| 29 | MyProj_3.2.7 | Develop Feature A estimate | 6h | 2008-08-07 | 2008-08-10 | 27 |  |  | 2008-08-07 | 2008-08-10 | 6h | 4d | 0d |  | David E | 6h |  | 6 | 6 |  |
| 30 | MyProj_3.2.8 | Develop Feature B estimate | 8h | 2008-08-11 | 2008-08-13 | 27 |  |  | 2008-08-11 | 2008-08-13 | 8h | 2d |  |  | Sarah B | 8h |  | 8 | 8 |  |
| 31 | MyProj_3.2.9 | Develop Feature C estimate | 8h | 2008-08-13 | 2008-08-14 | 27 |  |  | 2008-08-13 | 2008-08-14 | 8h | 0d |  |  | Sarah B | 8h |  | 8 | 8 |  |
| 32 | MyProj_3.2.10 | Develop User Documentation estimate | 4h | 2008-08-10 | 2008-08-11 | 29 |  |  | 2008-08-10 | 2008-08-11 | 4h | 4d |  |  | David E | 4h |  | 4 | 4 |  |

| ID | WBS | Task | Duration | Start | Finish | Predecessors | Baseline start | Baseline finish | Baseline duration | Total slack | Resources | Work | Cost | Baseline cost |
| --- | --- | --- | --- | --- | --- | --- | --- | --- | --- | --- | --- | --- | --- | --- |
| 33 | MyProj_3.3 | **Prepare Risk Management Plan** | 5d | 2008-08-17 | 2008-08-21 | 22 | 2008-08-17 | 2008-08-21 | 5d | 0d |  | 62h | 62 | 62 |
| 34 | MyProj_3.3.1 | Prepare list of Risks | 6h | 2008-08-17 | 2008-08-18 |  | 2008-08-17 | 2008-08-18 | 6h | 0d | David E; John N; Larry J; Sarah B | 24h | 24 | 24 |
| 35 | MyProj_3.3.2 | Review list with team (brainstorm) | 8h | 2008-08-18 | 2008-08-20 | 34 | 2008-08-18 | 2008-08-20 | 8h | 0d | David E; John N; Larry J; Sarah B | 32h | 32 | 32 |
| 36 | MyProj_3.3.3 | Develop Risk Management Plan | 6h | 2008-08-20 | 2008-08-21 | 35 | 2008-08-20 | 2008-08-21 | 6h | 0d | Larry J | 6h | 6 | 6 |
| 37 | MyProj_4 | **PRODUCT ARCHITECTURE** | 11d | 2008-08-21 | 2008-09-04 | 16 | 2008-08-21 | 2008-09-04 | 11d | 0d |  | 94h | 94 | 94 |
| 38 | MyProj_4.1 | Develop GUI architecture | 6h | 2008-08-26 | 2008-08-27 |  | 2008-08-26 | 2008-08-27 | 6h | 6.5d | David E | 6h | 6 | 6 |
| 39 | MyProj_4.2 | Develop operating environment architecture | 4h | 2008-08-21 | 2008-08-24 |  | 2008-08-21 | 2008-08-24 | 4h | 0d | David E | 4h | 4 | 4 |
| 40 | MyProj_4.3 | Develop feature set architecture | 12h | 2008-08-21 | 2008-08-26 |  | 2008-08-21 | 2008-08-26 | 12h | 8d | David E; Sarah B | 16h | 16 | 16 |
| 41 | MyProj_4.4 | Develop middleware architecture | 12h | 2008-08-24 | 2008-08-26 | 39 | 2008-08-24 | 2008-08-26 | 12h | 0d | John N; Larry J | 24h | 24 | 24 |
| 42 | MyProj_4.5 | Define key data structures | 12h | 2008-08-27 | 2008-08-31 | 41 | 2008-08-27 | 2008-08-31 | 12h | 0d | Sarah B | 12h | 12 | 12 |
| 43 | MyProj_4.6 | Define component interfaces | 8h | 2008-08-31 | 2008-09-02 | 42 | 2008-08-31 | 2008-09-02 | 8h | 0d | John N; David E | 16h | 16 | 16 |
| 44 | MyProj_4.7 | Define data flows | 8h | 2008-09-02 | 2008-09-04 | 43 | 2008-09-02 | 2008-09-04 | 8h | 0d | Sarah B; Larry J | 16h | 16 | 16 |
| 45 | MyProj_5 | **Detailed Design** | 12d | 2008-09-04 | 2008-09-18 | 37 | 2008-09-04 | 2008-09-18 | 12d | 0d |  | 48h | 48 | 48 |
| 46 | MyProj_5.1 | GUI Design | 12h | 2008-09-04 | 2008-09-08 |  | 2008-09-04 | 2008-09-08 | 12h | 0d | David E | 12h | 12 | 12 |
| 47 | MyProj_5.2 | Operating Environment Design | 16h | 2008-09-08 | 2008-09-11 | 46 | 2008-09-08 | 2008-09-11 | 16h | 0d | David E | 16h | 16 | 16 |
| 48 | MyProj_5.3 | Hardware Design | 14h | 2008-09-14 | 2008-09-17 | 47 | 2008-09-14 | 2008-09-17 | 14h | 0d | Larry J | 14h | 14 | 14 |
| 49 | MyProj_5.4 | Feature A Design | 6h | 2008-09-17 | 2008-09-18 | 48 | 2008-09-17 | 2008-09-18 | 6h | 0d | Sarah B | 6h | 6 | 6 |
| 50 | MyProj_6 | **Develop Product** | 24.5d | 2008-09-18 | 2008-10-19 | 49 | 2008-09-18 | 2008-10-19 | 24.5d | 0d |  | 98h | 98 | 98 |
| 51 | MyProj_6.1 | **Code and Unit Test GUI** | 5d | 2008-09-18 | 2008-09-24 |  | 2008-09-18 | 2008-09-24 | 5d | 0d |  | 20h | 20 | 20 |
| 52 | MyProj_6.1.1 | Code and test screen interface module | 6h | 2008-09-18 | 2008-09-21 |  | 2008-09-18 | 2008-09-21 | 6h | 0d | David E | 6h | 6 | 6 |
| 53 | MyProj_6.1.2 | Code and test data access module | 2h | 2008-09-21 | 2008-09-22 | 52 | 2008-09-21 | 2008-09-22 | 2h | 0d | John N | 2h | 2 | 2 |
| 54 | MyProj_6.1.3 | Code and test presentation services module | 8h | 2008-09-22 | 2008-09-23 | 53 | 2008-09-22 | 2008-09-23 | 8h | 0d | David E | 8h | 8 | 8 |
| 55 | MyProj_6.1.4 | Code and test error reporting module | 4h | 2008-09-24 | 2008-09-24 | 54 | 2008-09-24 | 2008-09-24 | 4h | 0d | John N | 4h | 4 | 4 |
| 56 | MyProj_6.2 | Code and Unit Test Operating Environment Modules | 20h | 2008-09-25 | 2008-10-01 | 55 | 2008-09-25 | 2008-10-01 | 20h | 0d | David E | 20h | 20 | 20 |
| 57 | MyProj_6.3 | Code and Unit Test Feature A | 12h | 2008-10-01 | 2008-10-05 | 56 | 2008-10-01 | 2008-10-05 | 12h | 0d | David E | 12h | 12 | 12 |
| 58 | MyProj_6.4 | Code and Unit Test Feature B | 10h | 2008-10-05 | 2008-10-07 | 57 | 2008-10-05 | 2008-10-07 | 10h | 0d | Sarah B | 10h | 10 | 10 |
| 59 | MyProj_6.5 | Code and Unit Test Feature C | 14h | 2008-10-08 | 2008-10-12 | 58 | 2008-10-08 | 2008-10-12 | 14h | 0d | Sarah B | 14h | 14 | 14 |
| 60 | MyProj_6.6 | Develop and Test Hardware (at XYZ Vendor) | 22h | 2008-10-13 | 2008-10-19 | 59 | 2008-10-13 | 2008-10-19 | 22h | 0d | Larry J | 22h | 22 | 22 |

Notes:
- 38: Need to add detailed architecture design tasks under this summary task (and those following) as required.
- 46: Need to add detailed design tasks under this summary task (and those following) as required.
- 56: Need to add detailed code and unit test tasks under this summary task (and those following) as required.

| ID | WBS | Task | Duration | Start | Finish | Predecessors | Baseline start | Baseline finish | Baseline duration | Total slack | Free slack | Resources | Work | Cost | Baseline cost |
| --- | --- | --- | --- | --- | --- | --- | --- | --- | --- | --- | --- | --- | --- | --- | --- |
| 61 | MyProj_7 | **Test Product** | 16.75d | 2008-10-19 | 2008-11-09 | 60 | 2008-10-19 | 2008-11-09 | 16.75d | 0d |  |  | 210h | 210 | 210 |
| 62 | MyProj_7.1 | Develop Product Test Plan | 8h | 2008-10-19 | 2008-10-21 | 45 | 2008-10-19 | 2008-10-21 | 8h | 0d |  | John N | 8h | 8 | 8 |
| 63 | MyProj_7.2 | Integrate and Test OE Modules | 22h | 2008-10-21 | 2008-11-09 | 62 | 2008-10-21 | 2008-11-09 | 22h | 0d |  | John N; David E; Larry J | 42h | 42 | 42 |
| 64 | MyProj_7.3 | Integrate and Test Feature Set Modules | 39h | 2008-10-19 | 2008-10-30 |  | 2008-10-19 | 2008-10-30 | 39h | 6.5d |  | Sarah B; John N | 40h | 40 | 40 |
| 65 | MyProj_7.4 | Intergrate and Test GUI | 12h | 2008-10-19 | 2008-10-22 |  | 2008-10-19 | 2008-10-22 | 12h | 0.75d | 0d | David E | 12h | 12 | 12 |
| 66 | MyProj_7.5 | Integrate Hardware and Software and Test | 8h | 2008-10-22 | 2008-10-28 | 65 | 2008-10-22 | 2008-10-28 | 8h | 0.75d | 0d | John N; David E | 8h | 8 | 8 |
| 67 | MyProj_7.6 | Function Test Data Flows | 12h | 2008-10-28 | 2008-10-30 | 66 | 2008-10-28 | 2008-10-30 | 12h | 0.75d | 0d | Sarah B | 12h | 12 | 12 |
| 68 | MyProj_7.7 | Systems Test Product | 22h | 2008-10-30 | 2008-11-06 | 67 | 2008-10-30 | 2008-11-06 | 22h | 0.75d |  | David E; John N; Larry J; Sarah B | 88h | 88 | 88 |

Notes:
- 62: Need to add detailed test development tasks under this summary task (and those following) as required.
- 63: Need to add detailed integration and testing tasks under this summary task (and those following) as required.
